# SUBPROYECTO A3

Schedule from Primavera P6, 2023-10-15 to 2024-04-27, data date 2023-10-15.

## Calendars

- 1T - 7x0 - 8 hr: Mon-Sun 08:00-16:00.

## Schedule

| ID | WBS | Activity | Type | Duration | Start | Finish | Predecessors | Total float | Free float |
| --- | --- | --- | --- | --- | --- | --- | --- | --- | --- |
|  | 0 | **HITOS** |  |  | 2023-10-15 | 2024-04-25 |  |  |  |
| A1000 |  | KICK OFF MEETING | milestone | 0d | 2023-10-15 | 2023-10-15 |  | 0d |  |
| A1010 |  | INICIO DEL SERVICIO | milestone | 0d | 2023-10-31 | 2023-10-31 | A1000 FS+16d | 0d |  |
| A1015 |  | INICIO DE EXCAVACIÓN | milestone | 0d | 2023-11-05 | 2023-11-05 | A1060 SS+5d | 0d |  |
| A1016 |  | INICIO DE RELLENO DE DIQUE | milestone | 0d | 2023-11-27 | 2023-11-27 | A1340 FS+1d | 0d |  |
| A1020 |  | FIN DEL SERVICIO | milestone | 0d | 2024-04-25 | 2024-04-25 | A1200, A2220, A2490, A1760, A1780, A1070, A2760, A2700, A1050, A2210, A4020, A3850, A3790, A3780, A3740, A3730, A3640, A3630, A3580, A3560, A3550, A3530, A3470, A3450, A3400, A3260, A3160, A3140, A3130, A3080, A2930, A2880, A4130, A4150, A4160, A2702, A1950 | 0d |  |
|  | 1 | **DEFENSAS RIBEREÑAS** |  |  | 2023-10-31 | 2024-04-27 |  |  |  |
|  | 1 | **OBRAS PRELIMINARES** |  |  | 2023-11-02 | 2024-04-23 |  |  |  |
| A1030 |  | CARTEL DE IDENTIFICACIÓN OBRA 4.80 x 3.60 m. |  | 2d | 2023-11-02 | 2023-11-03 | A1060 SS+2d | 176d |  |
| A1040 |  | INSTALACIONES PROVISIONALES PARA LA OBRA |  | 169d | 2023-11-05 | 2024-04-21 | A1015 | 6d |  |
| A1050 |  | MANTENIMIENTO DE TRÁNSITO Y SEGURIDAD VIAL |  | 154d | 2023-11-22 | 2024-04-23 | A1100 | 2d |  |
|  | 2 | **TRABAJOS PRELIMINARES** |  |  | 2023-10-31 | 2024-04-27 |  |  |  |
| A1060 |  | MOVILIZACION DE EQUIPOS |  | 31d | 2023-10-31 | 2023-11-30 | A1010 | 0d |  |
| A1070 |  | TOPOGRAFÍA Y GEOREFERENCIACIÓN |  | 174d | 2023-11-02 | 2024-04-23 | A1060 SS+2d | 2d | 0d |
| A1080 |  | DESMOVILIZACION DE EQUIPOS |  | 23d | 2024-04-05 | 2024-04-27 | A1020 FF+2d | 0d |  |
|  | 3 | **MEJORAMIENTO DE VÍAS EXISTENTES** |  |  | 2023-11-05 | 2024-01-04 |  |  |  |
|  | 1 | **MOVIMIENTO DE TIERRAS** |  |  | 2023-11-05 | 2023-11-21 |  |  |  |
| A1090 |  | ROCE Y LIMPIEZA DE MALEZA |  | 17d | 2023-11-05 | 2023-11-21 | A1015 | 2d | 0d |
| A1100 |  | MEJORAMIENTO DE VIAS EXISTENTES |  | 17d | 2023-11-05 | 2023-11-21 | A1090 SS | 2d | 0d |
|  | 2 | **REPOSICIÓN DE ESTRUCTURAS** |  |  | 2023-11-25 | 2023-12-29 |  |  |  |
| A1150 |  | DEMOLICIÓN DE ESTRUCTURAS EXISTENTES |  | 2d | 2023-11-25 | 2023-11-26 | A1070 SS+23d | 112d | 0d |
| A1160 |  | REPOSICIÓN DE PASE DE AGUA TUBO HDPE Ø=18" |  | 2d | 2023-11-28 | 2023-11-29 | A1150 SS+3d | 112d | 0d |
| A1170 |  | REPOSICIÓN DE PASE DE AGUA TUBO HDPE Ø=36" |  | 2d | 2023-11-28 | 2023-11-29 | A1160 SS | 112d | 0d |
| A1180 |  | SUMINISTRO Y MONTAJE DE PANELES DE C°A° 1.6mx1.0mx0.20m EN PASE DE AGUA |  | 30d | 2023-11-30 | 2023-12-29 | A1170 SS+2d | 112d | 0d |
| A1190 |  | SUMINISTRO Y MONTAJE DE PANELES DE C°A° 2.20mx1.0mx0.20m EN PASE DE AGUA |  | 30d | 2023-11-30 | 2023-12-29 | A1180 SS | 112d | 0d |

| ID | WBS | Activity | Duration | Start | Finish | Predecessors | Total float | Free float | Filtro |
| --- | --- | --- | --- | --- | --- | --- | --- | --- | --- |
|  | 4 | **CABEZAL DE ENTRADA Y SALIDA** |  | 2023-12-30 | 2024-01-04 |  |  |  |  |
| A1210 |  | ENCOFRADO Y DESENCOFRADO RECTO | 3d | 2023-12-30 | 2024-01-01 | A1190 | 112d | 0d |  |
| A1200 |  | CONCRETOS | 3d | 2024-01-02 | 2024-01-04 | A1210 | 112d |  |  |
|  | 4 | **DESCOLMATACIÓN DE CAUCE Y OBRAS AUXILIARES** |  | 2023-11-06 | 2024-02-25 |  |  |  |  |
|  | 1 | **DESBROCE Y DESCOLMATACIÓN** |  | 2023-11-06 | 2024-01-30 |  |  |  |  |
| A1220 |  | DESBROCE Y LIMPIEZA EN ZONA NO BOSCOSA | 76d | 2023-11-06 | 2024-01-20 | A1015 FS+1d | 0d |  | Excavación |
| A1230 |  | DESCOLMATACIÓN DE CAUCE NATURAL DEL RÍO LACRAMARCA - DIQUE A3-D-01 | 10d | 2023-11-06 | 2023-11-15 | A1220 SS | 0d |  | Excavación |
| A1880 |  | DESCOLMATACIÓN DE CAUCE NATURAL DEL RÍO LACRAMARCA - DIQUE A3-I-01 | 32d | 2023-11-06 | 2023-12-07 | A1230 SS | 0d |  | Excavación |
| A1870 |  | DESCOLMATACIÓN DE CAUCE NATURAL DEL RÍO LACRAMARCA - DIQUE A3-D-02 | 53d | 2023-11-16 | 2024-01-07 | A1230 | 40d |  | Excavación |
| A1890 |  | DESCOLMATACIÓN DE CAUCE NATURAL DEL RÍO LACRAMARCA - DIQUE A3-I-02 | 20d | 2023-12-08 | 2023-12-27 | A1880 | 13d | 0d | Excavación |
| A1900 |  | DESCOLMATACIÓN DE CAUCE NATURAL DEL RÍO LACRAMARCA - DIQUE A3-I-03 | 34d | 2023-12-28 | 2024-01-30 | A1890 | 88d |  | Excavación |
|  | 2 | **DESVIO DEL CAUCE** |  | 2023-11-07 | 2024-02-25 |  |  |  |  |
|  | 1 | **A3-D-01** |  | 2023-12-11 | 2023-12-20 |  |  |  |  |
| A1240 |  | CONFORMACIÓN DE DESVIO EN CAUCE DE RÍO - DIQUE A3-D-01 | 5d | 2023-12-11 | 2023-12-15 | A1330 SS+9d | 0d |  | Excavación |
| A1250 |  | RELLENO NO ESTRUCTURAL CON MATERIAL PROPIO - DIQUE A3-D-01 | 7d | 2023-12-14 | 2023-12-20 | A1330 | 129d |  | Relleno |
|  | 2 | **A3-D-02** |  | 2023-12-28 | 2024-02-25 |  |  |  |  |
| A1790 |  | CONFORMACIÓN DE DESVIO EN CAUCE DE RÍO - DIQUE A3-D-02 - TRAMO 1 | 5d | 2023-12-28 | 2024-01-01 | A1870 SS+2d, A1510 FF+2d | 0d |  | Excavación |
| A1800 |  | RELLENO NO ESTRUCTURAL CON MATERIAL PROPIO - DIQUE A3-D-02 - TRAMO 1 | 7d | 2024-01-02 | 2024-01-08 | A1790 | 60d | 0d | Relleno |
| A2650 |  | CONFORMACIÓN DE DESVIO EN CAUCE DE RÍO - DIQUE A3-D-02 - TRAMO 3 | 5d | 2024-01-09 | 2024-01-13 | A1800 | 60d | 0d | Excavación |
| A2660 |  | RELLENO NO ESTRUCTURAL CON MATERIAL PROPIO - DIQUE A3-D-02 - TRAMO 3 | 7d | 2024-01-14 | 2024-01-20 | A2650 | 60d | 0d | Relleno |
| A2670 |  | CONFORMACIÓN DE DESVIO EN CAUCE DE RÍO - DIQUE A3-D-02 - TRAMO 4 | 5d | 2024-01-21 | 2024-01-25 | A2660 | 60d | 0d | Excavación |
| A2680 |  | RELLENO NO ESTRUCTURAL CON MATERIAL PROPIO - DIQUE A3-D-02 - TRAMO 4 | 7d | 2024-01-26 | 2024-02-01 | A2670 | 60d | 0d | Relleno |
| A2690 |  | CONFORMACIÓN DE DESVIO EN CAUCE DE RÍO - DIQUE A3-D-02 - TRAMO 5 | 5d | 2024-02-02 | 2024-02-06 | A2680 | 60d | 0d | Excavación |
| A2700 |  | RELLENO NO ESTRUCTURAL CON MATERIAL PROPIO - DIQUE A3-D-02 - TRAMO 5 | 7d | 2024-02-07 | 2024-02-13 | A2690 | 60d | 0d | Relleno |
| A2701 |  | CONFORMACIÓN DE DESVIO EN CAUCE DE RÍO - DIQUE A3-D-02 - TRAMO 2 | 5d | 2024-02-14 | 2024-02-18 | A2700 | 60d | 0d | Excavación |
| A2702 |  | RELLENO NO ESTRUCTURAL CON MATERIAL PROPIO - DIQUE A3-D-02 - TRAMO 2 | 7d | 2024-02-19 | 2024-02-25 | A2701 | 60d |  | Relleno |

| ID | WBS | Activity | Duration | Start | Finish | Predecessors | Total float | Free float | Filtro |
| --- | --- | --- | --- | --- | --- | --- | --- | --- | --- |
|  | 3 | **A3-I-01** |  | 2023-11-07 | 2024-01-06 |  |  |  |  |
| A1810 |  | CONFORMACIÓN DE DESVIO EN CAUCE DE RÍO - DIQUE A3-I-01 | 5d | 2023-11-07 | 2023-11-11 | A1880 SS+1d | 0d |  | Excavación |
| A1820 |  | RELLENO NO ESTRUCTURAL CON MATERIAL PROPIO - DIQUE A3-I-01 | 7d | 2023-12-31 | 2024-01-06 | A1510 | 105d | 17d | Relleno |
|  | 4 | **A3-I-02** |  | 2023-12-11 | 2024-01-30 |  |  |  |  |
| A1830 |  | CONFORMACIÓN DE DESVIO EN CAUCE DE RÍO - DIQUE A3-I-02 | 5d | 2023-12-11 | 2023-12-15 | A1890 SS+2d, A1330 FF+2d | 12d | 0d | Excavación |
| A1840 |  | RELLENO NO ESTRUCTURAL CON MATERIAL PROPIO - DIQUE A3-I-02 | 7d | 2024-01-24 | 2024-01-30 | A1600, A1820 | 88d |  | Relleno |
|  | 5 | **A3-I-03** |  | 2024-01-02 | 2024-02-18 |  |  |  |  |
| A1845 |  | CONFORMACIÓN DE DESVIO EN CAUCE DE RÍO - DIQUE A3-I-03 - TRAMO 2 | 5d | 2024-01-02 | 2024-01-06 | A1790 | 67d | 0d | Excavación |
| A1846 |  | RELLENO NO ESTRUCTURAL CON MATERIAL PROPIO - DIQUE A3-I-03 -TRAMO 2 | 7d | 2024-01-07 | 2024-01-13 | A1845 | 67d | 0d | Relleno |
| A1850 |  | CONFORMACIÓN DE DESVIO EN CAUCE DE RÍO - DIQUE A3-I-03 - TRAMO 1 | 5d | 2024-01-14 | 2024-01-18 | A1846 | 67d | 0d | Excavación |
| A1860 |  | RELLENO NO ESTRUCTURAL CON MATERIAL PROPIO - DIQUE A3-I-03 -TRAMO 1 | 7d | 2024-01-19 | 2024-01-25 | A1850 | 67d | 0d | Relleno |
| A2730 |  | CONFORMACIÓN DE DESVIO EN CAUCE DE RÍO - DIQUE A3-I-03 - TRAMO 3 | 5d | 2024-01-26 | 2024-01-30 | A1860 | 67d | 0d | Excavación |
| A2740 |  | RELLENO NO ESTRUCTURAL CON MATERIAL PROPIO - DIQUE A3-I-03 -TRAMO 3 | 7d | 2024-01-31 | 2024-02-06 | A2730 | 67d | 0d | Relleno |
| A2750 |  | CONFORMACIÓN DE DESVIO EN CAUCE DE RÍO - DIQUE A3-I-03 - TRAMO 4 | 5d | 2024-02-07 | 2024-02-11 | A2740 | 67d | 0d | Excavación |
| A2760 |  | RELLENO NO ESTRUCTURAL CON MATERIAL PROPIO - DIQUE A3-I-03 -TRAMO 4 | 7d | 2024-02-12 | 2024-02-18 | A2750 | 67d |  | Relleno |
|  | 5 | **DIQUES DE TIERRA COMPACTADA CON ENROCADO** |  | 2023-11-12 | 2024-04-25 |  |  |  |  |
|  | 1 | **DIQUE DE TIERRA COMPACTADA A3-D-01** |  | 2023-11-12 | 2023-12-16 |  |  |  |  |
| A1260 |  | EXCAVACIÓN EN TERRENO NATURAL CON EQUIPO | 10d | 2023-11-12 | 2023-11-21 | A1810 | 0d |  | Excavación |
| A1270 |  | EXCAVACIÓN DE UÑA CON EQUIPO | 9d | 2023-11-13 | 2023-11-21 | A1260 SS+1d | 136d | 25d | Excavación |
| A1280 |  | PERFILADO Y COMPACTACIÓN EN ZONA DE CORTE | 20d | 2023-11-13 | 2023-12-02 | A1260 SS+1d | 0d |  |  |
| A1340 |  | PREPARACIÓN DE FUNDACIÓN DE CUERPO DE DIQUE | 13d | 2023-11-13 | 2023-11-25 | A1280 SS | 0d |  |  |
| A1290 |  | CONFORMACIÓN DE CUERPO DE DIQUE CON MATERIAL PROPIO | 5d | 2023-11-27 | 2023-12-01 | A1016 | 0d |  | Relleno |
| A1310 |  | GEOTEXTIL NO TEJIDO 400 G/M2, INC. COLOCACIÓN | 6d | 2023-11-29 | 2023-12-04 | A1290 SS+2d | 0d |  |  |
| A1320 |  | COLOCACION Y ACOMODO DE ROCA EN UÑA DE DIQUE | 6d | 2023-11-30 | 2023-12-05 | A1310 SS+1d | 0d |  | Roca |
| A1330 |  | COLOCACION Y ACOMODO DE ROCA EN TALUD DE DIQUE | 12d | 2023-12-02 | 2023-12-13 | A1320 SS+2d | 0d |  | Roca |
| A1300 |  | CONFORMACIÓN DE CORONA DE DIQUE CON MATERIAL PROPIO | 6d | 2023-12-11 | 2023-12-16 | A1330 FF+3d | 133d |  | Relleno |

| ID | WBS | Activity | Duration | Start | Finish | Predecessors | Total float | Free float | Filtro |
| --- | --- | --- | --- | --- | --- | --- | --- | --- | --- |
|  | 2 | **DIQUE DE TIERRA COMPACTADA A3-D-02** |  | 2023-12-16 | 2024-04-13 |  |  |  |  |
|  | 1 | **TRAMO 1** |  | 2023-12-16 | 2024-01-08 |  |  |  |  |
| A1350 |  | EXCAVACIÓN EN TERRENO NATURAL CON EQUIPO | 9d | 2023-12-16 | 2023-12-24 | A1830 | 12d | 0d | Excavación |
| A1360 |  | EXCAVACIÓN DE UÑA CON EQUIPO | 11d | 2023-12-17 | 2023-12-27 | A1350 SS+1d, A1270 | 111d | 85d | Excavación |
| A1370 |  | PERFILADO Y COMPACTACIÓN EN ZONA DE CORTE | 12d | 2023-12-17 | 2023-12-28 | A1350 SS+1d | 12d | 0d |  |
| A1400 |  | GEOTEXTIL NO TEJIDO 400 G/M2, INC. COLOCACIÓN | 13d | 2023-12-19 | 2023-12-31 | A1370 SS+2d | 12d | 0d |  |
| A1410 |  | COLOCACION Y ACOMODO DE ROCA EN UÑA DE DIQUE | 16d | 2023-12-21 | 2024-01-05 | A1400 SS+2d | 12d | 0d | Roca |
| A1420 |  | COLOCACION Y ACOMODO DE ROCA EN TALUD DE DIQUE | 15d | 2023-12-23 | 2024-01-06 | A1410 SS+2d | 12d | 0d | Roca |
| A1430 |  | PREPARACIÓN DE FUNDACIÓN DE CUERPO DE DIQUE | 5d | 2023-12-25 | 2023-12-29 | A1350 | 114d | 0d |  |
| A1380 |  | CONFORMACIÓN DE CUERPO DE DIQUE CON MATERIAL PROPIO | 5d | 2023-12-26 | 2023-12-30 | A1430 SS+1d | 114d | 91d | Relleno |
| A1390 |  | CONFORMACIÓN DE CORONA DE DIQUE CON MATERIAL PROPIO | 6d | 2024-01-03 | 2024-01-08 | A1420 SS+11d | 12d | 0d | Relleno |
|  | 2 | **TRAMO 2 (PROG 22+500 - 22+860)** |  | 2024-03-21 | 2024-04-13 |  |  |  |  |
| A1910 |  | EXCAVACIÓN EN TERRENO NATURAL CON EQUIPO | 9d | 2024-03-21 | 2024-03-29 | A2220 | 12d | 0d | Excavación |
| A1920 |  | EXCAVACIÓN DE UÑA CON EQUIPO | 11d | 2024-03-22 | 2024-04-01 | A1910 SS+1d, A1360 | 26d |  | Excavación |
| A1930 |  | PERFILADO Y COMPACTACIÓN EN ZONA DE CORTE | 12d | 2024-03-22 | 2024-04-02 | A1910 SS+1d | 12d | 0d |  |
| A1960 |  | GEOTEXTIL NO TEJIDO 400 G/M2, INC. COLOCACIÓN | 12d | 2024-03-24 | 2024-04-04 | A1930 SS+2d | 12d | 0d |  |
| A1970 |  | COLOCACION Y ACOMODO DE ROCA EN UÑA DE DIQUE | 16d | 2024-03-26 | 2024-04-10 | A1960 SS+2d | 12d | 0d | Roca |
| A1980 |  | COLOCACION Y ACOMODO DE ROCA EN TALUD DE DIQUE | 15d | 2024-03-28 | 2024-04-11 | A1970 SS+2d | 12d | 0d | Roca |
| A1990 |  | PREPARACIÓN DE FUNDACIÓN DE CUERPO DE DIQUE | 5d | 2024-03-30 | 2024-04-03 | A1910 | 23d | 0d |  |
| A1940 |  | CONFORMACIÓN DE CUERPO DE DIQUE CON MATERIAL PROPIO | 5d | 2024-03-31 | 2024-04-04 | A1990 SS+1d, A1380 | 23d |  | Relleno |
| A1950 |  | CONFORMACIÓN DE CORONA DE DIQUE CON MATERIAL PROPIO | 6d | 2024-04-08 | 2024-04-13 | A1980 SS+11d | 12d |  | Relleno |
|  | 3 | **TRAMO 3** |  | 2024-01-09 | 2024-02-01 |  |  |  |  |
| A2000 |  | EXCAVACIÓN EN TERRENO NATURAL CON EQUIPO | 9d | 2024-01-09 | 2024-01-17 | A1390 | 12d | 0d | Excavación |
| A2010 |  | EXCAVACIÓN DE UÑA CON EQUIPO | 11d | 2024-01-10 | 2024-01-20 | A2000 SS+1d | 65d | 13d | Excavación |
| A2020 |  | PERFILADO Y COMPACTACIÓN EN ZONA DE CORTE | 12d | 2024-01-10 | 2024-01-21 | A2000 SS+1d | 12d | 0d |  |
| A2050 |  | GEOTEXTIL NO TEJIDO 400 G/M2, INC. COLOCACIÓN | 12d | 2024-01-12 | 2024-01-23 | A2020 SS+2d | 12d | 0d |  |
| A2060 |  | COLOCACION Y ACOMODO DE ROCA EN UÑA DE DIQUE | 16d | 2024-01-14 | 2024-01-29 | A2050 SS+2d | 12d | 0d | Roca |
| A2070 |  | COLOCACION Y ACOMODO DE ROCA EN TALUD DE DIQUE | 15d | 2024-01-16 | 2024-01-30 | A2060 SS+2d | 12d | 0d | Roca |
| A2080 |  | PREPARACIÓN DE FUNDACIÓN DE CUERPO DE DIQUE | 5d | 2024-01-18 | 2024-01-22 | A2000 | 83d | 0d |  |
| A2030 |  | CONFORMACIÓN DE CUERPO DE DIQUE CON MATERIAL PROPIO | 5d | 2024-01-19 | 2024-01-23 | A2080 SS+1d | 83d | 19d | Relleno |
| A2040 |  | CONFORMACIÓN DE CORONA DE DIQUE CON MATERIAL PROPIO | 6d | 2024-01-27 | 2024-02-01 | A2070 SS+11d | 12d | 0d | Relleno |

| ID | WBS | Activity | Duration | Start | Finish | Predecessors | Total float | Free float | Filtro |
| --- | --- | --- | --- | --- | --- | --- | --- | --- | --- |
|  | 4 | **TRAMO 4** |  | 2024-02-02 | 2024-02-25 |  |  |  |  |
| A2090 |  | EXCAVACIÓN EN TERRENO NATURAL CON EQUIPO | 9d | 2024-02-02 | 2024-02-10 | A2040 | 12d | 0d | Excavación |
| A2100 |  | EXCAVACIÓN DE UÑA CON EQUIPO | 11d | 2024-02-03 | 2024-02-13 | A2090 SS+1d, A2010 | 52d | 13d | Excavación |
| A2110 |  | PERFILADO Y COMPACTACIÓN EN ZONA DE CORTE | 12d | 2024-02-03 | 2024-02-14 | A2090 SS+1d | 12d | 0d |  |
| A2140 |  | GEOTEXTIL NO TEJIDO 400 G/M2, INC. COLOCACIÓN | 12d | 2024-02-05 | 2024-02-16 | A2110 SS+2d | 12d | 0d |  |
| A2150 |  | COLOCACION Y ACOMODO DE ROCA EN UÑA DE DIQUE | 16d | 2024-02-07 | 2024-02-22 | A2140 SS+2d | 12d | 0d | Roca |
| A2160 |  | COLOCACION Y ACOMODO DE ROCA EN TALUD DE DIQUE | 15d | 2024-02-09 | 2024-02-23 | A2150 SS+2d | 12d | 0d | Roca |
| A2170 |  | PREPARACIÓN DE FUNDACIÓN DE CUERPO DE DIQUE | 5d | 2024-02-11 | 2024-02-15 | A2090 | 64d | 0d |  |
| A2120 |  | CONFORMACIÓN DE CUERPO DE DIQUE CON MATERIAL PROPIO | 5d | 2024-02-12 | 2024-02-16 | A2170 SS+1d, A2030 | 64d | 19d | Relleno |
| A2130 |  | CONFORMACIÓN DE CORONA DE DIQUE CON MATERIAL PROPIO | 6d | 2024-02-20 | 2024-02-25 | A2160 SS+11d | 12d | 0d | Relleno |
|  | 5 | **TRAMO 5** |  | 2024-02-26 | 2024-03-20 |  |  |  |  |
| A2180 |  | EXCAVACIÓN EN TERRENO NATURAL CON EQUIPO | 9d | 2024-02-26 | 2024-03-05 | A2130 | 12d | 0d | Excavación |
| A2190 |  | EXCAVACIÓN DE UÑA CON EQUIPO | 11d | 2024-02-27 | 2024-03-08 | A2180 SS+1d, A2100 | 39d | 0d | Excavación |
| A2200 |  | PERFILADO Y COMPACTACIÓN EN ZONA DE CORTE | 12d | 2024-02-27 | 2024-03-09 | A2180 SS+1d | 12d | 0d |  |
| A2230 |  | GEOTEXTIL NO TEJIDO 400 G/M2, INC. COLOCACIÓN | 12d | 2024-02-28 | 2024-03-10 | A2200 SS+1d | 12d | 0d |  |
| A2240 |  | COLOCACION Y ACOMODO DE ROCA EN UÑA DE DIQUE | 16d | 2024-03-01 | 2024-03-16 | A2230 SS+2d | 12d | 0d | Roca |
| A2250 |  | COLOCACION Y ACOMODO DE ROCA EN TALUD DE DIQUE | 15d | 2024-03-03 | 2024-03-17 | A2240 SS+2d | 12d | 0d | Roca |
| A2260 |  | PREPARACIÓN DE FUNDACIÓN DE CUERPO DE DIQUE | 5d | 2024-03-06 | 2024-03-10 | A2180 | 45d | 0d |  |
| A2210 |  | CONFORMACIÓN DE CUERPO DE DIQUE CON MATERIAL PROPIO | 5d | 2024-03-07 | 2024-03-11 | A2260 SS+1d, A2120 | 45d |  | Relleno |
| A2220 |  | CONFORMACIÓN DE CORONA DE DIQUE CON MATERIAL PROPIO | 6d | 2024-03-15 | 2024-03-20 | A2250 FF+3d, A2130 | 12d | 0d | Relleno |
|  | 3 | **DIQUE DE TIERRA COMPACTADA A3-I-01** |  | 2023-12-16 | 2024-01-22 |  |  |  |  |
|  | 1 | **Sector liberado** |  | 2023-12-16 | 2024-01-02 |  |  |  |  |
| A1440 |  | EXCAVACIÓN EN TERRENO NATURAL CON EQUIPO | 7d | 2023-12-16 | 2023-12-22 | A1240 | 0d |  | Excavación |
| A1450 |  | EXCAVACIÓN DE UÑA CON EQUIPO | 6d | 2023-12-17 | 2023-12-22 | A1440 SS+1d | 113d | 11d | Excavación |
| A1460 |  | PERFILADO Y COMPACTACIÓN EN ZONA DE CORTE | 7d | 2023-12-17 | 2023-12-23 | A1440 SS+1d | 0d |  |  |
| A1520 |  | PREPARACIÓN DE FUNDACIÓN DE CUERPO DE DIQUE | 5d | 2023-12-17 | 2023-12-21 | A1460 SS | 0d |  |  |
| A1470 |  | CONFORMACIÓN DE CUERPO DE DIQUE CON MATERIAL PROPIO | 5d | 2023-12-18 | 2023-12-22 | A1520 SS+1d | 0d |  | Relleno |
| A1490 |  | GEOTEXTIL NO TEJIDO 400 G/M2, INC. COLOCACIÓN | 4d | 2023-12-20 | 2023-12-23 | A1470 SS+2d | 0d |  |  |
| A1500 |  | COLOCACION Y ACOMODO DE ROCA EN UÑA DE DIQUE | 4d | 2023-12-22 | 2023-12-25 | A1490 SS+2d | 0d |  | Roca |
| A1510 |  | COLOCACION Y ACOMODO DE ROCA EN TALUD DE DIQUE | 7d | 2023-12-24 | 2023-12-30 | A1500 SS+2d | 0d |  | Roca |
| A1480 |  | CONFORMACIÓN DE CORONA DE DIQUE CON MATERIAL PROPIO | 3d | 2023-12-31 | 2024-01-02 | A1510 FF+3d | 96d | 0d | Relleno |

| ID | WBS | Activity | Duration | Start | Finish | Predecessors | Total float | Free float | Filtro |
| --- | --- | --- | --- | --- | --- | --- | --- | --- | --- |
|  | 2 | **Sector por Liberar - Km 20+980 - km 21+300** |  | 2024-01-03 | 2024-01-22 |  |  |  |  |
| A4030 |  | EXCAVACIÓN EN TERRENO NATURAL CON EQUIPO | 4d | 2024-01-03 | 2024-01-06 | A1480 | 96d | 0d | Excavación |
| A4040 |  | EXCAVACIÓN DE UÑA CON EQUIPO | 3d | 2024-01-06 | 2024-01-08 | A4030 SS+3d | 96d | 0d | Excavación |
| A4050 |  | PERFILADO Y COMPACTACIÓN EN ZONA DE CORTE | 4d | 2024-01-07 | 2024-01-10 | A4030 | 96d | 0d |  |
| A4110 |  | PREPARACIÓN DE FUNDACIÓN DE CUERPO DE DIQUE | 3d | 2024-01-08 | 2024-01-10 | A4050 SS+1d | 96d | 0d |  |
| A4060 |  | CONFORMACIÓN DE CUERPO DE DIQUE CON MATERIAL PROPIO | 3d | 2024-01-09 | 2024-01-11 | A4110 SS+1d, A4040 | 96d | 0d | Relleno |
| A4080 |  | GEOTEXTIL NO TEJIDO 400 G/M2, INC. COLOCACIÓN | 2d | 2024-01-11 | 2024-01-12 | A4060 SS+2d, A4050 | 96d | 0d |  |
| A4090 |  | COLOCACION Y ACOMODO DE ROCA EN UÑA DE DIQUE | 2d | 2024-01-13 | 2024-01-14 | A4080 | 96d | 0d | Roca |
| A4100 |  | COLOCACION Y ACOMODO DE ROCA EN TALUD DE DIQUE | 5d | 2024-01-15 | 2024-01-19 | A4090 | 96d | 0d | Roca |
| A4070 |  | CONFORMACIÓN DE CORONA DE DIQUE CON MATERIAL PROPIO | 2d | 2024-01-21 | 2024-01-22 | A4100 FF+3d | 96d |  | Relleno |
|  | 4 | **DIQUE DE TIERRA COMPACTADA A3-I-02** |  | 2024-01-02 | 2024-01-25 |  |  |  |  |
| A1530 |  | EXCAVACIÓN EN TERRENO NATURAL CON EQUIPO | 15d | 2024-01-02 | 2024-01-16 | A1790 | 0d |  | Excavación |
| A1540 |  | EXCAVACIÓN DE UÑA CON EQUIPO | 14d | 2024-01-03 | 2024-01-16 | A1530 SS+1d, A1450 | 102d |  | Excavación |
| A1550 |  | PERFILADO Y COMPACTACIÓN EN ZONA DE CORTE | 11d | 2024-01-06 | 2024-01-16 | A1530 SS+4d | 0d |  |  |
| A1580 |  | GEOTEXTIL NO TEJIDO 400 G/M2, INC. COLOCACIÓN | 11d | 2024-01-08 | 2024-01-18 | A1550 SS+2d | 0d |  |  |
| A1590 |  | COLOCACION Y ACOMODO DE ROCA EN UÑA DE DIQUE | 10d | 2024-01-10 | 2024-01-19 | A1580 SS+2d | 0d |  | Roca |
| A1610 |  | PREPARACIÓN DE FUNDACIÓN DE CUERPO DE DIQUE | 3d | 2024-01-10 | 2024-01-12 | A1530 SS+8d | 105d | 0d |  |
| A1560 |  | CONFORMACIÓN DE CUERPO DE DIQUE CON MATERIAL PROPIO | 3d | 2024-01-11 | 2024-01-13 | A1610 SS+1d | 105d |  | Relleno |
| A1600 |  | COLOCACION Y ACOMODO DE ROCA EN TALUD DE DIQUE | 12d | 2024-01-12 | 2024-01-23 | A1590 SS+2d | 0d |  | Roca |
| A1570 |  | CONFORMACIÓN DE CORONA DE DIQUE CON MATERIAL PROPIO | 6d | 2024-01-20 | 2024-01-25 | A1600 SS+8d | 0d |  | Relleno |
|  | 5 | **DIQUE DE TIERRA COMPACTADA A3-I-03** |  | 2024-01-26 | 2024-04-25 |  |  |  |  |
|  | 1 | **TRAMO 1** |  | 2024-02-12 | 2024-03-07 |  |  |  |  |
| A1620 |  | EXCAVACIÓN EN TERRENO NATURAL CON EQUIPO | 7d | 2024-02-12 | 2024-02-18 | A2310 | 0d |  | Excavación |
| A1630 |  | EXCAVACIÓN DE UÑA CON EQUIPO | 11d | 2024-02-13 | 2024-02-23 | A1620 SS+1d | 8d |  | Excavación |
| A1640 |  | PERFILADO Y COMPACTACIÓN EN ZONA DE CORTE | 12d | 2024-02-13 | 2024-02-24 | A1620 SS+1d | 0d |  |  |
| A1670 |  | GEOTEXTIL NO TEJIDO 400 G/M2, INC. COLOCACIÓN | 12d | 2024-02-14 | 2024-02-25 | A1640 SS+1d | 0d |  |  |
| A1680 |  | COLOCACION Y ACOMODO DE ROCA EN UÑA DE DIQUE | 16d | 2024-02-16 | 2024-03-02 | A1670 SS+2d | 0d |  | Roca |
| A1690 |  | COLOCACION Y ACOMODO DE ROCA EN TALUD DE DIQUE | 15d | 2024-02-18 | 2024-03-03 | A1680 SS+2d | 0d |  | Roca |
| A1700 |  | PREPARACIÓN DE FUNDACIÓN DE CUERPO DE DIQUE | 5d | 2024-02-19 | 2024-02-23 | A1620 | 8d |  |  |
| A1660 |  | CONFORMACIÓN DE CORONA DE DIQUE CON MATERIAL PROPIO | 6d | 2024-02-29 | 2024-03-05 | A1690 SS+11d | 2d |  | Relleno |
| A1650 |  | CONFORMACIÓN DE CUERPO DE DIQUE CON MATERIAL PROPIO | 5d | 2024-03-03 | 2024-03-07 | A1690 SS+14d, A1630, A1700 | 0d |  | Relleno |

| ID | WBS | Activity | Duration | Start | Finish | Predecessors | Total float | Free float | Filtro |
| --- | --- | --- | --- | --- | --- | --- | --- | --- | --- |
|  | 2 | **TRAMO 2** |  | 2024-01-26 | 2024-04-25 |  |  |  |  |
|  | 1 | **Sector liberado** |  | 2024-01-26 | 2024-02-11 |  |  |  |  |
| A2270 |  | EXCAVACIÓN EN TERRENO NATURAL CON EQUIPO | 4d | 2024-01-26 | 2024-01-29 | A1570 | 0d |  | Excavación |
| A2280 |  | EXCAVACIÓN DE UÑA CON EQUIPO | 7d | 2024-01-27 | 2024-02-02 | A2270 SS+1d | 55d | 35d | Excavación |
| A2290 |  | PERFILADO Y COMPACTACIÓN EN ZONA DE CORTE | 8d | 2024-01-27 | 2024-02-03 | A2270 SS+1d | 0d |  |  |
| A2320 |  | GEOTEXTIL NO TEJIDO 400 G/M2, INC. COLOCACIÓN | 7d | 2024-01-28 | 2024-02-03 | A2290 SS+1d | 0d |  |  |
| A2330 |  | COLOCACION Y ACOMODO DE ROCA EN UÑA DE DIQUE | 10d | 2024-01-30 | 2024-02-08 | A2320 SS+2d | 0d |  | Roca |
| A2350 |  | PREPARACIÓN DE FUNDACIÓN DE CUERPO DE DIQUE | 3d | 2024-01-30 | 2024-02-01 | A2270 | 65d | 0d |  |
| A2300 |  | CONFORMACIÓN DE CUERPO DE DIQUE CON MATERIAL PROPIO | 3d | 2024-01-31 | 2024-02-02 | A2350 SS+1d | 65d | 42d | Relleno |
| A2340 |  | COLOCACION Y ACOMODO DE ROCA EN TALUD DE DIQUE | 9d | 2024-02-01 | 2024-02-09 | A2330 SS+2d | 0d |  | Roca |
| A2310 |  | CONFORMACIÓN DE CORONA DE DIQUE CON MATERIAL PROPIO | 3d | 2024-02-09 | 2024-02-11 | A2340 SS+8d | 0d |  | Relleno |
|  | 2 | **Sector por Liberar - Km 23+760 - km 24+100** |  | 2024-04-04 | 2024-04-25 |  |  |  |  |
| A4120 |  | EXCAVACIÓN EN TERRENO NATURAL CON EQUIPO | 3d | 2024-04-04 | 2024-04-06 | A2450 SS+5d | 0d |  | Excavación |
| A4130 |  | EXCAVACIÓN DE UÑA CON EQUIPO | 4d | 2024-04-06 | 2024-04-09 | A4120 SS+2d | 0d |  | Excavación |
| A4140 |  | PERFILADO Y COMPACTACIÓN EN ZONA DE CORTE | 5d | 2024-04-08 | 2024-04-12 | A4120 SS+1d, A4130 SS+2d | 0d |  |  |
| A4200 |  | PREPARACIÓN DE FUNDACIÓN DE CUERPO DE DIQUE | 2d | 2024-04-08 | 2024-04-09 | A4140 SS | 0d |  |  |
| A4150 |  | CONFORMACIÓN DE CUERPO DE DIQUE CON MATERIAL PROPIO | 2d | 2024-04-09 | 2024-04-10 | A4200 SS+1d, A4140 SS | 15d |  | Relleno |
| A4170 |  | GEOTEXTIL NO TEJIDO 400 G/M2, INC. COLOCACIÓN | 3d | 2024-04-10 | 2024-04-12 | A4200 | 0d |  |  |
| A4180 |  | COLOCACION Y ACOMODO DE ROCA EN UÑA DE DIQUE | 7d | 2024-04-13 | 2024-04-19 | A4170 | 0d |  | Roca |
| A4190 |  | COLOCACION Y ACOMODO DE ROCA EN TALUD DE DIQUE | 6d | 2024-04-18 | 2024-04-23 | A4180 SS+5d | 0d |  | Roca |
| A4160 |  | CONFORMACIÓN DE CORONA DE DIQUE CON MATERIAL PROPIO | 2d | 2024-04-24 | 2024-04-25 | A4190 | 0d |  | Relleno |
|  | 3 | **TRAMO 3** |  | 2024-03-08 | 2024-03-29 |  |  |  |  |
| A2360 |  | EXCAVACIÓN EN TERRENO NATURAL CON EQUIPO | 7d | 2024-03-08 | 2024-03-14 | A2310, A1650, A1660 | 0d |  | Excavación |
| A2370 |  | EXCAVACIÓN DE UÑA CON EQUIPO | 11d | 2024-03-09 | 2024-03-19 | A2360 SS+1d, A2280 | 20d | 11d | Excavación |
| A2380 |  | PERFILADO Y COMPACTACIÓN EN ZONA DE CORTE | 12d | 2024-03-09 | 2024-03-20 | A2360 SS+1d | 0d |  |  |
| A2410 |  | GEOTEXTIL NO TEJIDO 400 G/M2, INC. COLOCACIÓN | 12d | 2024-03-10 | 2024-03-21 | A2380 SS+1d | 0d |  |  |
| A2420 |  | COLOCACION Y ACOMODO DE ROCA EN UÑA DE DIQUE | 16d | 2024-03-12 | 2024-03-27 | A2410 SS+2d | 0d |  | Roca |
| A2430 |  | COLOCACION Y ACOMODO DE ROCA EN TALUD DE DIQUE | 15d | 2024-03-14 | 2024-03-28 | A2420 SS+2d | 0d |  | Roca |
| A2440 |  | PREPARACIÓN DE FUNDACIÓN DE CUERPO DE DIQUE | 5d | 2024-03-15 | 2024-03-19 | A2360 | 23d | 0d |  |
| A2390 |  | CONFORMACIÓN DE CUERPO DE DIQUE CON MATERIAL PROPIO | 5d | 2024-03-16 | 2024-03-20 | A2440 SS+1d, A2300 | 23d | 17d | Relleno |
| A2400 |  | CONFORMACIÓN DE CORONA DE DIQUE CON MATERIAL PROPIO | 6d | 2024-03-24 | 2024-03-29 | A2430 SS+10d | 0d |  | Relleno |

| ID | WBS | Activity | Duration | Start | Finish | Predecessors | Total float | Free float | Filtro |
| --- | --- | --- | --- | --- | --- | --- | --- | --- | --- |
|  | 4 | **TRAMO 4** |  | 2024-03-30 | 2024-04-22 |  |  |  |  |
| A2450 |  | EXCAVACIÓN EN TERRENO NATURAL CON EQUIPO | 7d | 2024-03-30 | 2024-04-05 | A2400 | 0d |  | Excavación |
| A2460 |  | EXCAVACIÓN DE UÑA CON EQUIPO | 11d | 2024-03-31 | 2024-04-10 | A2450 SS+1d, A2370 | 9d | 0d | Excavación |
| A2470 |  | PERFILADO Y COMPACTACIÓN EN ZONA DE CORTE | 12d | 2024-03-31 | 2024-04-11 | A2450 SS+1d | 3d | 0d |  |
| A2500 |  | GEOTEXTIL NO TEJIDO 400 G/M2, INC. COLOCACIÓN | 12d | 2024-04-01 | 2024-04-12 | A2470 SS+1d | 3d | 0d |  |
| A2510 |  | COLOCACION Y ACOMODO DE ROCA EN UÑA DE DIQUE | 16d | 2024-04-03 | 2024-04-18 | A2500 SS+2d | 3d | 0d | Roca |
| A2520 |  | COLOCACION Y ACOMODO DE ROCA EN TALUD DE DIQUE | 15d | 2024-04-05 | 2024-04-19 | A2510 SS+2d | 3d | 0d | Roca |
| A2530 |  | PREPARACIÓN DE FUNDACIÓN DE CUERPO DE DIQUE | 5d | 2024-04-06 | 2024-04-10 | A2450 | 6d | 0d |  |
| A2480 |  | CONFORMACIÓN DE CUERPO DE DIQUE CON MATERIAL PROPIO | 5d | 2024-04-07 | 2024-04-11 | A2530 SS+1d, A2390 | 6d | 2d | Relleno |
| A2490 |  | CONFORMACIÓN DE CORONA DE DIQUE CON MATERIAL PROPIO | 6d | 2024-04-17 | 2024-04-22 | A2520 FF+3d, A2400 | 3d |  | Relleno |
|  | 6 | **RAMPAS** |  | 2024-03-09 | 2024-04-16 |  |  |  |  |
|  | 1 | **A3-RA-D-01** |  | 2024-03-09 | 2024-03-14 |  |  |  |  |
| A1710 |  | EXCAVACIÓN EN TERRENO NATURAL CON EQUIPO | 3d | 2024-03-09 | 2024-03-11 | A2190 | 39d | 0d | Excavación |
| A1720 |  | CONFORMACIÓN DE CUERPO DE RAMPA CON MATERIAL PROPIO | 3d | 2024-03-12 | 2024-03-14 | A1710 | 39d | 0d | Relleno |
| A1730 |  | CONFORMACIÓN DE CORONACIÓN DE RAMPA | 3d | 2024-03-12 | 2024-03-14 | A1720 SS | 39d | 30d | Relleno |
|  | 2 | **A3-RA-I-01** |  | 2024-04-11 | 2024-04-16 |  |  |  |  |
| A1740 |  | EXCAVACIÓN EN TERRENO NATURAL CON EQUIPO | 3d | 2024-04-11 | 2024-04-13 | A2460 | 9d | 0d | Excavación |
| A1750 |  | CONFORMACIÓN DE CUERPO DE RAMPA CON MATERIAL PROPIO | 3d | 2024-04-14 | 2024-04-16 | A1740 | 9d | 0d | Relleno |
| A1760 |  | CONFORMACIÓN DE CORONACIÓN DE RAMPA | 3d | 2024-04-14 | 2024-04-16 | A1750 SS, A1730 | 9d |  | Relleno |
|  | 2 | **OBRAS DE ARTE** |  | 2023-11-06 | 2024-04-22 |  |  |  |  |
|  | 1 | **CAPTACIÓN A3-CP-23-95** |  | 2023-11-21 | 2024-03-18 |  |  |  |  |
|  | 1 | **MOVIMIENTO DE TIERRAS** |  | 2023-11-21 | 2024-01-07 |  |  |  |  |
| A2770 |  | EXCAVACIÓN ESTRUCTURAL PARA OBRAS DE ARTE | 6d | 2023-11-21 | 2023-11-26 | A3390 | 38d | 0d |  |
| A2780 |  | RELLENO ESTRUCTURAL PARA OBRAS DE ARTE, CON MATERIAL PROPIO | 5d | 2024-01-03 | 2024-01-07 | A2800 FS+12d | 90d | 1d |  |

| ID | WBS | Activity | Duration | Start | Finish | Predecessors | Total float | Free float |
| --- | --- | --- | --- | --- | --- | --- | --- | --- |
|  | 2 | **OBRAS DE CONCRETO** |  | 2023-11-27 | 2023-12-21 |  |  |  |
| A2790 |  | CONCRETO f'c=100 kg/cm2 | 3d | 2023-11-27 | 2023-11-29 | A2770 | 50d | 0d |
| A2810 |  | CONCRETO CICLÓPEO f'c=280 kg/cm2 + 30% P.G. | 3d | 2023-11-30 | 2023-12-02 | A2790 | 50d | 0d |
| A2830 |  | ACERO DE REFUERZO fy=4200 kg/cm2 | 13d | 2023-12-03 | 2023-12-15 | A2810 | 50d | 0d |
| A2820 |  | ENCOFRADO Y DESENCOFRADO RECTO | 10d | 2023-12-07 | 2023-12-16 | A2830 FF+1d | 53d | 0d |
| A2800 |  | CONCRETO f'c=280 kg/cm2 | 12d | 2023-12-10 | 2023-12-21 | A2820 SS+3d | 55d | 0d |
|  | 3 | **ESTRUCTURAS METALICAS** |  | 2024-01-03 | 2024-01-17 |  |  |  |
| A2840 |  | COMPUERTA METALICA PLANA DESLIZANTE DE 1.0x1.0m | 3d | 2024-01-03 | 2024-01-05 | A2800 FS+12d | 99d | 0d |
| A2850 |  | REJILLA DE 1.00x1.00m CON VARILLA DE 1/2" CADA 6,25cm | 3d | 2024-01-06 | 2024-01-08 | A2840 | 99d | 0d |
| A2860 |  | BARANDA DE FIERRO GALVANIZADO 1 1/2" | 3d | 2024-01-09 | 2024-01-11 | A2850 | 99d | 0d |
| A2870 |  | ESCALERA TIPO GATO | 3d | 2024-01-12 | 2024-01-14 | A2860 | 99d | 0d |
| A2880 |  | TAPA METALICA CIRCULAR DN600 MM | 3d | 2024-01-15 | 2024-01-17 | A2870 | 99d |  |
|  | 4 | **TUBERIAS** |  | 2023-11-27 | 2024-01-23 |  |  |  |
| A2890 |  | EXCAVACIÓN ESTRUCTURAL PARA OBRAS DE ARTE (Buzones) | 3d | 2023-11-27 | 2023-11-29 | A2770 | 38d | 0d |
| A2900 |  | EXCAVACIÓN DE ZANJA | 25d | 2023-11-30 | 2023-12-24 | A2890 | 38d | 0d |
| A2920 |  | CAMA DE ARENA | 25d | 2023-12-03 | 2023-12-27 | A2900 SS+3d | 93d | 0d |
| A2940 |  | CONCRETO f'c=100 kg/cm2 (Buzones) | 3d | 2023-12-03 | 2023-12-05 | A2900 SS+3d, A2790 | 60d | 10d |
| A2990 |  | SUMINISTRO E INSTALACIÓN DE TUBERÍA GRP DN600 mm SN2500 | 25d | 2023-12-04 | 2023-12-28 | A2920 SS+1d | 93d | 0d |
| A2980 |  | ACERO DE REFUERZO fy=4200 kg/cm2 (Buzones) | 4d | 2023-12-16 | 2023-12-19 | A2940, A2830 | 50d | 0d |
| A2960 |  | ENCOFRADO Y DESENCOFRADO RECTO | 5d | 2023-12-20 | 2023-12-24 | A2820, A2980 | 50d | 0d |
| A2970 |  | ENCOFRADO Y DESENCOFRADO CURVO | 5d | 2023-12-20 | 2023-12-24 | A2960 SS | 50d | 0d |
| A2950 |  | CONCRETO f'c=280 kg/cm2 (Buzones) | 3d | 2023-12-25 | 2023-12-27 | A2970, A2800 | 52d | 0d |
| A2930 |  | RELLENO COMÚN PARA ZANJAS | 26d | 2023-12-29 | 2024-01-23 | A2990 | 93d |  |
| A2910 |  | RELLENO ESTRUCTURAL PARA OBRAS DE ARTE CON MATERIAL PROPIO (Buzones) | 3d | 2024-01-09 | 2024-01-11 | A2950 FS+12d, A2780 | 89d | 0d |

| ID | WBS | Activity | Duration | Start | Finish | Predecessors | Total float | Free float |
| --- | --- | --- | --- | --- | --- | --- | --- | --- |
|  | 5 | **CANAL** |  | 2023-12-25 | 2024-02-29 |  |  |  |
| A3000 |  | EXCAVACIÓN ESTRUCTURAL PARA OBRAS DE ARTE | 6d | 2023-12-25 | 2023-12-30 | A2900 | 38d | 0d |
| A3020 |  | COLOCACIÓN DE CONCRETO f'c=100 kg/cm2 | 4d | 2023-12-31 | 2024-01-03 | A2940, A3000 | 38d | 0d |
| A3050 |  | ACERO DE REFUERZO fy=4200 kg/cm2 | 28d | 2024-01-04 | 2024-01-31 | A2980, A3020 | 38d | 0d |
| A3040 |  | ENCOFRADO Y DESENCOFRADO RECTO | 52d | 2024-01-06 | 2024-02-26 | A2970, A3050 SS+2d | 38d | 0d |
| A3030 |  | COLOCACIÓN DE CONCRETO f'c=280 kg/cm2 | 53d | 2024-01-08 | 2024-02-29 | A2950 SS, A3040 SS+2d | 38d | 0d |
| A3060 |  | JUNTA WATER STOP SIN BULBO 150 mm | 53d | 2024-01-08 | 2024-02-29 | A3030 SS | 53d | 3d |
| A3010 |  | RELLENO ESTRUCTURAL PARA CANALES, CON MATERIAL PROPIO | 13d | 2024-01-12 | 2024-01-24 | A2910 | 89d | 51d |
|  | 6 | **OBRAS DE DESCARGA** |  | 2023-12-31 | 2024-03-18 |  |  |  |
| A3070 |  | EXCAVACIÓN ESTRUCTURAL PARA OBRAS DE ARTE | 3d | 2023-12-31 | 2024-01-02 | A3000 | 87d | 1d |
| A3090 |  | CONCRETO f'c=100 kg/cm2 | 3d | 2024-01-04 | 2024-01-06 | A3070, A3020 | 86d | 25d |
| A3120 |  | ACERO DE REFUERZO fy=4200 kg/cm2 | 3d | 2024-02-01 | 2024-02-03 | A3090, A3050 | 61d | 23d |
| A3110 |  | ENCOFRADO Y DESENCOFRADO RECTO | 3d | 2024-02-27 | 2024-02-29 | A3120, A3040 | 38d | 0d |
| A3100 |  | CONCRETO f'c=280 kg/cm2 | 3d | 2024-03-01 | 2024-03-03 | A3110, A3030 | 38d | 0d |
| A3130 |  | JUNTA WATER STOP SIN BULBO 150 mm | 3d | 2024-03-04 | 2024-03-06 | A3100, A3060 | 50d |  |
| A3080 |  | RELLENO ESTRUCTURAL PARA OBRAS DE ARTE CON MATERIAL PROPIO | 3d | 2024-03-16 | 2024-03-18 | A3100 FS+12d, A3010 | 38d |  |
| A3140 |  | COMPUERTA METALICA PLANA DESLIZANTE | 3d | 2024-03-16 | 2024-03-18 | A3100 FS+12d | 38d |  |
|  | 2 | **CAPTACIÓN A3-CP-21-05** |  | 2023-11-09 | 2024-02-06 |  |  |  |
|  | 1 | **MOVIMIENTO DE TIERRAS** |  | 2023-11-09 | 2023-12-28 |  |  |  |
| A3150 |  | EXCAVACIÓN ESTRUCTURAL PARA OBRAS DE ARTE | 4d | 2023-11-09 | 2023-11-12 | A1070 SS+7d | 38d | 0d |
| A3160 |  | RELLENO ESTRUCTURAL PARA OBRAS DE ARTE, CON MATERIAL PROPIO | 5d | 2023-12-24 | 2023-12-28 | A3180 FS+12d | 119d |  |
|  | 2 | **OBRAS DE CONCRETO** |  | 2023-11-13 | 2023-12-11 |  |  |  |
| A3170 |  | CONCRETO f'c=100 kg/cm2 | 3d | 2023-11-13 | 2023-11-15 | A3150 | 79d | 0d |
| A3190 |  | CONCRETO CICLÓPEO f'c=280 kg/cm2 + 30% P.G. | 3d | 2023-11-16 | 2023-11-18 | A3170 | 79d | 0d |
| A3210 |  | ACERO DE REFUERZO fy=4200 kg/cm2 | 21d | 2023-11-19 | 2023-12-09 | A3190 | 79d | 0d |
| A3200 |  | ENCOFRADO Y DESENCOFRADO RECTO | 15d | 2023-11-25 | 2023-12-09 | A3210 SS+6d | 82d | 0d |
| A3180 |  | CONCRETO f'c=280 kg/cm2 | 11d | 2023-12-01 | 2023-12-11 | A3200 SS+6d | 109d | 0d |

| ID | WBS | Activity | Duration | Start | Finish | Predecessors | Total float | Free float |
| --- | --- | --- | --- | --- | --- | --- | --- | --- |
|  | 3 | **ESTRUCTURAS METALICAS** |  | 2023-12-24 | 2024-01-07 |  |  |  |
| A3220 |  | COMPUERTA METALICA PLANA DESLIZANTE DE 1.0x1.0m | 3d | 2023-12-24 | 2023-12-26 | A3180 FS+12d | 109d | 0d |
| A3230 |  | REJILLA DE 1.00x1.00m CON VARILLA DE 1/2 CADA 6,25cm | 3d | 2023-12-27 | 2023-12-29 | A3220 | 109d | 0d |
| A3240 |  | BARANDA DE FIERRO GALVANIZADO 1 1/2" | 3d | 2023-12-30 | 2024-01-01 | A3230 | 109d | 0d |
| A3250 |  | ESCALERA TIPO GATO | 3d | 2024-01-02 | 2024-01-04 | A3240 | 109d | 0d |
| A3260 |  | TAPA METALICA CIRCULAR DN600 MM | 3d | 2024-01-05 | 2024-01-07 | A3250 | 109d |  |
|  | 4 | **TUBERIA** |  | 2023-11-13 | 2024-01-02 |  |  |  |
| A3270 |  | EXCAVACIÓN ESTRUCTURAL PARA OBRAS DE ARTE (Buzones) | 3d | 2023-11-13 | 2023-11-15 | A3150 | 38d | 0d |
| A3280 |  | EXCAVACIÓN DE ZANJA | 3d | 2023-11-16 | 2023-11-18 | A3270 | 143d | 0d |
| A3330 |  | CONCRETO f'c=100 kg/cm2 (Buzones) | 3d | 2023-11-16 | 2023-11-18 | A3270, A3170 | 100d | 2d |
| A3300 |  | CAMA DE ARENA | 3d | 2023-11-19 | 2023-11-21 | A3280 | 143d | 0d |
| A3380 |  | SUMINISTRO E INSTALACIÓN DE TUBERÍA GRP DN600 mm SN2500 | 3d | 2023-11-22 | 2023-11-24 | A3300 | 143d | 0d |
| A3310 |  | RELLENO SELECCIONADO PARA ZANJAS CON MATERIAL PROPIO | 3d | 2023-11-25 | 2023-11-27 | A3320 SS | 143d | 64d |
| A3320 |  | RELLENO COMÚN PARA ZANJAS | 3d | 2023-11-25 | 2023-11-27 | A3380 | 143d | 0d |
| A3370 |  | ACERO DE REFUERZO fy=4200 kg/cm2 | 3d | 2023-12-10 | 2023-12-12 | A3330, A3210 | 79d | 0d |
| A3350 |  | ENCOFRADO Y DESENCOFRADO RECTO | 3d | 2023-12-13 | 2023-12-15 | A3370, A3200 | 79d | 0d |
| A3360 |  | ENCOFRADO Y DESENCOFRADO CURVO | 3d | 2023-12-13 | 2023-12-15 | A3350 SS | 79d | 0d |
| A3340 |  | CONCRETO f'c=280 kg/cm2 (Buzones) | 3d | 2023-12-16 | 2023-12-18 | A3360, A3180 | 105d | 0d |
| A3290 |  | RELLENO ESTRUCTURAL PARA OBRAS DE ARTE CON MATERIAL PROPIO | 3d | 2023-12-31 | 2024-01-02 | A3340 FS+12d | 107d | 28d |
|  | 5 | **CANALES** |  | 2023-11-16 | 2024-02-06 |  |  |  |
| A3390 |  | EXCAVACIÓN ESTRUCTURAL PARA OBRAS DE ARTE | 5d | 2023-11-16 | 2023-11-20 | A3270 | 38d | 0d |
| A3410 |  | COLOCACIÓN DE CONCRETO f'c=100 kg/cm2 | 3d | 2023-11-21 | 2023-11-23 | A3390, A3330 | 98d | 19d |
| A3440 |  | ACERO DE REFUERZO fy=4200 kg/cm2 | 12d | 2023-12-13 | 2023-12-24 | A3410, A3370 | 79d | 0d |
| A3430 |  | ENCOFRADO Y DESENCOFRADO | 29d | 2023-12-16 | 2024-01-13 | A3440 SS+3d, A3360 | 79d | 0d |
| A3420 |  | COLOCACIÓN DE CONCRETO f'c=280 kg/cm2 | 5d | 2024-01-14 | 2024-01-18 | A3430, A3340 | 79d | 0d |
| A3450 |  | JUNTA WATER STOP SIN BULBO 150 mm | 3d | 2024-01-14 | 2024-01-16 | A3420 SS | 100d |  |
| A3400 |  | RELLENO ESTRUCTURAL PARA CANALES, CON MATERIAL PROPIO | 7d | 2024-01-31 | 2024-02-06 | A3420 FS+12d, A3290, A3310 | 79d |  |

| ID | WBS | Activity | Duration | Start | Finish | Predecessors | Total float | Free float |
| --- | --- | --- | --- | --- | --- | --- | --- | --- |
|  | 3 | **RETORNO A3-OA-RE-D-21-55** |  | 2023-11-06 | 2023-12-29 |  |  |  |
|  | 1 | **MOVIMIENTO DE TIERRAS** |  | 2023-11-06 | 2023-12-25 |  |  |  |
| A3460 |  | EXCAVACIÓN ESTRUCTURAL PARA OBRAS DE ARTE | 3d | 2023-11-06 | 2023-11-08 | A1070 SS+4d | 118d | 0d |
| A3470 |  | RELLENO ESTRUCTURAL PARA OBRAS DE ARTE, CON MATERIAL PROPIO | 3d | 2023-12-23 | 2023-12-25 | A3490 FS+12d | 122d |  |
|  | 2 | **OBRAS DE CONCRETO** |  | 2023-11-09 | 2023-12-10 |  |  |  |
| A3480 |  | CONCRETO f'c=100 kg/cm2 | 3d | 2023-11-09 | 2023-11-11 | A3460 | 118d | 0d |
| A3500 |  | CONCRETO CICLÓPEO f'c=280 kg/cm2 + 30% P.G. | 5d | 2023-11-12 | 2023-11-16 | A3480 | 118d | 0d |
| A3520 |  | ACERO DE REFUERZO fy=4200 kg/cm2 | 24d | 2023-11-12 | 2023-12-05 | A3500 SS | 118d | 0d |
| A3510 |  | ENCOFRADO Y DESENCOFRADO | 18d | 2023-11-18 | 2023-12-05 | A3520 SS+6d | 118d | 0d |
| A3490 |  | CONCRETO f'c=280 kg/cm2 | 5d | 2023-12-06 | 2023-12-10 | A3510 | 118d | 0d |
| A3530 |  | JUNTA WATER STOP SIN BULBO 150 mm | 5d | 2023-12-06 | 2023-12-10 | A3490 SS | 137d |  |
|  | 3 | **ESTRUCTURAS METALICAS** |  | 2023-12-23 | 2023-12-29 |  |  |  |
| A3540 |  | COMPUERTA METALICA PLANA DESLIZANTE DE 1.0x1.6 m | 4d | 2023-12-23 | 2023-12-26 | A3490 FS+12d | 118d | 0d |
| A3550 |  | BARANDA DE FIERRO GALVANIZADO 1 1/2" | 3d | 2023-12-27 | 2023-12-29 | A3540 | 118d |  |
|  | 4 | **REPOSICIÓN DE CANALES** |  | 2023-11-22 | 2024-04-22 |  |  |  |
|  | 1 | **REPOSICIÓN DE CANAL 1** |  | 2024-01-17 | 2024-04-22 |  |  |  |
|  | 1 | **MOVIMIENTO DE TIERRAS** |  | 2024-01-17 | 2024-04-22 |  |  |  |
| A3560 |  | DEMOLICIÓN DE ESTRUCTURAS EXISTENTES | 17d | 2024-01-17 | 2024-02-02 | A1530 | 83d |  |
| A3570 |  | EXCAVACIÓN EN TERRENO NATURAL CON EQUIPO | 36d | 2024-01-24 | 2024-02-28 | A1600 | 3d | 0d |
| A3580 |  | RELLENO ESTRUCTURAL PARA OBRAS DE ARTE CON MATERIAL PROPIO | 39d | 2024-03-15 | 2024-04-22 | A3620 SS+20d, A3670 | 3d |  |
|  | 2 | **OBRAS DE CONCRETO** |  | 2024-01-31 | 2024-04-20 |  |  |  |
| A3610 |  | CONCRETO f'c=100 kg/cm2 | 36d | 2024-01-31 | 2024-03-06 | A3570 SS+7d | 3d | 0d |
| A3600 |  | ACERO DE REFUERZO fy=4200 kg/cm2 | 70d | 2024-02-03 | 2024-04-12 | A3610 SS+3d | 3d | 0d |
| A3590 |  | ENCOFRADO Y DESENCOFRADO RECTO | 63d | 2024-02-10 | 2024-04-12 | A3600 SS+7d | 3d | 0d |
| A3620 |  | CONCRETO f'c=280 kg/cm2 | 54d | 2024-02-24 | 2024-04-17 | A3590 SS+14d | 3d | 0d |
| A3630 |  | JUNTA WATER STOP 6" | 54d | 2024-02-24 | 2024-04-17 | A3620 SS | 8d |  |
| A3640 |  | MAMPOSTERIA DE PIEDRA, e=20cm, ACABADO CARA VISTA | 3d | 2024-04-18 | 2024-04-20 | A3620 | 5d |  |

| ID | WBS | Activity | Duration | Start | Finish | Predecessors | Total float | Free float |
| --- | --- | --- | --- | --- | --- | --- | --- | --- |
|  | 2 | **REPOSICIÓN DE CANAL 3** |  | 2023-11-22 | 2024-01-19 |  |  |  |
|  | 1 | **MOVIMIENTO DE TIERRAS** |  | 2023-11-22 | 2024-01-19 |  |  |  |
| A3650 |  | DEMOLICIÓN DE ESTRUCTURAS EXISTENTES | 10d | 2023-11-22 | 2023-12-01 | A1260 | 70d | 12d |
| A3660 |  | EXCAVACIÓN EN TERRENO NATURAL CON EQUIPO | 4d | 2023-12-14 | 2023-12-17 | A1330, A3650 | 58d | 0d |
| A3670 |  | RELLENO ESTRUCTURAL PARA OBRAS DE ARTE CON MATERIAL PROPIO | 3d | 2024-01-17 | 2024-01-19 | A3720 FS+6d | 58d | 55d |
|  | 2 | **OBRAS DE CONCRETO** |  | 2023-12-18 | 2024-01-13 |  |  |  |
| A3710 |  | CONCRETO f'c=100 kg/cm2 | 4d | 2023-12-18 | 2023-12-21 | A3660 | 58d | 0d |
| A3700 |  | MALLA ELECTROSOLDADA DE DN6mm EN CUADRICULA 15x15 cm | 15d | 2023-12-22 | 2024-01-05 | A3710 | 58d | 0d |
| A3680 |  | ENCOFRADO Y DESENCOFRADO PARA REVESTIMIENTO DE CANALES (CERCHAS) | 12d | 2023-12-25 | 2024-01-05 | A3700 SS+3d | 58d | 0d |
| A3690 |  | ENCOFRADO Y DESENCOFRADO RECTO | 12d | 2023-12-25 | 2024-01-05 | A3680 SS | 58d | 0d |
| A3730 |  | SELLO DE JUNTA CONSTRUCCIÓN CON MATERIAL ELASTOMÉRICO | 10d | 2023-12-25 | 2024-01-03 | A3680 SS | 113d |  |
| A3720 |  | CONCRETO f'c=280 kg/cm2 | 5d | 2024-01-06 | 2024-01-10 | A3690 | 58d | 0d |
| A3740 |  | MAMPOSTERIA DE PIEDRA, e=20cm, ACABADO CARA VISTA | 3d | 2024-01-11 | 2024-01-13 | A3720 | 103d |  |
|  | 5 | **REPOSICIÓN SIFON INOPERATIVO** |  | 2023-12-08 | 2024-01-16 |  |  |  |
| A3750 |  | DEMOLICIÓN DE ESTRUCTURAS EXISTENTES | 3d | 2023-12-08 | 2023-12-10 | A1230, A1880 | 100d | 0d |
| A3760 |  | EXCAVACIÓN ESTRUCTURAL PARA OBRAS DE ARTE | 10d | 2023-12-11 | 2023-12-20 | A3750 | 100d | 0d |
| A3770 |  | COLOCACIÓN CAMA DE ARENA | 3d | 2023-12-21 | 2023-12-23 | A3760 | 109d | 0d |
| A3810 |  | CONCRETO f'c=100 kg/cm2 | 3d | 2023-12-21 | 2023-12-23 | A3760 | 100d | 0d |
| A3800 |  | TUBERÍAS DE 14" HDPE SDR21 DN 355mm | 6d | 2023-12-24 | 2023-12-29 | A3770 | 109d | 0d |
| A3840 |  | ACERO DE REFUERZO fy=4200 kg/cm2 | 3d | 2023-12-24 | 2023-12-26 | A3810 | 100d | 0d |
| A3850 |  | CODOS HDPE DE 14" DN 355mm | 6d | 2023-12-24 | 2023-12-29 | A3800 SS | 118d |  |
| A3830 |  | ENCOFRADO Y DESENCOFRADO RECTO | 3d | 2023-12-27 | 2023-12-29 | A3840 | 100d | 0d |
| A3790 |  | RELLENO COMÚN | 9d | 2023-12-30 | 2024-01-07 | A3800 | 109d |  |
| A3820 |  | CONCRETO f'c=280 kg/cm2 | 3d | 2023-12-30 | 2024-01-01 | A3830 | 100d | 0d |
| A3780 |  | RELLENO ESTRUCTURAL PARA OBRAS DE ARTE CON MATERIAL PROPIO | 3d | 2024-01-14 | 2024-01-16 | A3820 FS+12d | 100d |  |

| ID | WBS | Activity | Duration | Start | Finish | Predecessors | Total float | Free float | Filtro |
| --- | --- | --- | --- | --- | --- | --- | --- | --- | --- |
|  | 3 | **ARQUITECTURA Y PAISAJISMO** |  | 2024-01-26 | 2024-04-08 |  |  |  |  |
|  | 1 | **OBRAS PRELIMINARES** |  | 2024-01-26 | 2024-04-08 |  |  |  |  |
| A3860 |  | MOVILIZACIÓN DE EQUIPOS Y HERRAMIENTAS (ARQUITECTURA Y PAISAJISMO) | 2d | 2024-01-26 | 2024-01-27 | A1570 | 17d | 0d |  |
| A3870 |  | TRAZO Y REPLANTEO PRELIMINAR | 2d | 2024-01-28 | 2024-01-29 | A3860 | 17d | 0d |  |
| A4020 |  | DEMOVILIZACIÓN DE EQUIPOS Y HERRAMIENTAS (ARQUITECTURA Y PAISAJISMO) | 2d | 2024-04-07 | 2024-04-08 | A4010, A3900 | 17d |  |  |
|  | 2 | **MOVIMIENTO DE TIERRAS** |  | 2024-01-30 | 2024-02-15 |  |  |  |  |
| A3880 |  | EXCAVACIÓN MANUAL PARA INSTALACIÓN DE BORDILLOS Y CIMENTACIONES | 2d | 2024-01-30 | 2024-01-31 | A3870 | 17d | 0d |  |
| A3900 |  | ELIMINACION DE MATERIAL EXCEDENTE (DME´S) | 17d | 2024-01-30 | 2024-02-15 | A3880 SS | 68d | 51d |  |
| A3890 |  | EXCAVACIÓN PARA MEJORAMIENTO DE SUELO CON TIERRA VEGETAL | 15d | 2024-02-01 | 2024-02-15 | A3880 | 17d | 0d |  |
|  | 3 | **PAVIMENTOS, RECUBRIMIENTOS Y BORDILLOS** |  | 2024-02-16 | 2024-02-26 |  |  |  |  |
| A3910 |  | PISO DE GRAVILLA | 2d | 2024-02-16 | 2024-02-17 | A3890 | 17d | 0d |  |
| A3920 |  | RECUBRIMIENTO DE PIEDRA DEL LUGAR e=0.05cm | 4d | 2024-02-18 | 2024-02-21 | A3910 | 17d | 0d |  |
| A3930 |  | BORDILLOS DE PIEDRA DEL LUGAR | 5d | 2024-02-22 | 2024-02-26 | A3920 | 17d | 0d |  |
|  | 4 | **MOBILIARIOS, BARANDAS Y ESCALERAS** |  | 2024-02-27 | 2024-04-04 |  |  |  |  |
| A3940 |  | ESCALERA DE CONCRETO SOBRE ENROCADO, CIMENTACION Y ANCLAJE | 10d | 2024-02-27 | 2024-03-07 | A3930 | 17d | 0d |  |
| A3950 |  | BARANDA DE MADERA EUCALIPTO CON SOGA, INCLUYE CIMENTACIÓN | 4d | 2024-03-08 | 2024-03-11 | A3940 | 17d | 0d |  |
| A3960 |  | TACHOS DE BASURA, INCLUYE CIMENTACIÓN | 3d | 2024-03-12 | 2024-03-14 | A3950 | 17d | 0d |  |
| A3970 |  | BANCAS DE CONCRETO, INCLUYE CIMENTACIÓN | 10d | 2024-03-15 | 2024-03-24 | A3960 | 17d | 0d |  |
| A3980 |  | POSTES DE ILUMINACIÓN, INCLUYE LUMINARIA Y CIMENTACIÓN | 5d | 2024-03-25 | 2024-03-29 | A3970 | 17d | 0d |  |
| A3990 |  | SEÑALETICA INFORMATIVA | 3d | 2024-03-30 | 2024-04-01 | A3980 | 17d | 0d |  |
| A4000 |  | BOLARDOS DE PIEDRA | 3d | 2024-04-02 | 2024-04-04 | A3990 | 17d | 0d |  |
|  | 5 | **INSTALACIÓN DE ALCORQUES** |  | 2024-04-05 | 2024-04-06 |  |  |  |  |
| A4010 |  | ALCORQUES DE PIEDRA DE CANTO RODADO PARA ARBOLES | 2d | 2024-04-05 | 2024-04-06 | A4000 | 17d | 0d |  |
|  | 4 | **PROGRAMA DE CIERRE DE OBRA** |  | 2023-11-06 | 2024-04-21 |  |  |  |  |
| A1770 |  | ACONDICIONAMIENTO DE DEPOSITOS DE MATERIALES EXCEDENTES (DME) | 160d | 2023-11-06 | 2024-04-13 | A1220 SS | 4d | 0d | Excavación |
| A1780 |  | RESTAURACIÓN DE ÁREAS DE INSTALACIONES PROVISIONALES | 8d | 2024-04-14 | 2024-04-21 | A2480, A1770 | 4d |  |  |
